# Puerto_Caldera_IFC_INCOP v8

How a schedule from MS Project changed from version to version. A marks actual dates.

## Version 1 (saved 2025-03-14, file Puerto_Caldera_IFC_INCOP v8.mpp)

| ID | WBS | Task | Duration | Start | Finish | Predecessors | Complete | Total float | Constraint |
| --- | --- | --- | --- | --- | --- | --- | --- | --- | --- |
| 1 |  | Inicio | 1d | 2023-05-31 | 2023-05-31 |  |  | 834d |  |
| 2 |  | Refrendo del Contrato de Servicios de Asesoría Transaccional por la CGR | 1d | 2023-05-22 A | 2023-05-22 A |  | 100% |  | must start on 2023-05-22 |
| 3 | 3 | **Contratación Consultores de la CFI** | 20d | 2023-05-31 A | 2023-06-27 A |  | 100% |  |  |
| 4 |  | Técnico | 8d | 2023-05-31 A | 2023-06-09 A |  | 100% |  |  |
| 5 |  | Ambiental y Social | 11d | 2023-05-31 A | 2023-06-14 A |  | 100% |  |  |
| 6 |  | Legal | 20d | 2023-05-31 A | 2023-06-27 A |  | 100% |  |  |
| 7 |  | Comunicación | 20d | 2023-05-31 A | 2023-06-27 A |  | 100% |  |  |
| 8 |  | Costo Beneficio, Riesgos y Valor por dinero | 20d | 2023-05-31 A | 2023-06-27 A |  | 100% |  |  |
| 9 | 4 | **Fase 1 - Preinversión, Inversión y Cartel** | 362d | 2023-06-12 A | 2024-10-29 |  | 96% | 465d |  |
| 10 |  | Reunión inicial: Plan de Trabajo | 3d | 2023-06-14 A | 2023-06-16 A |  | 100% |  | start no earlier than 2023-06-14 |
| 11 |  | Consultas comité para socialización del Proyecto (MIDEPLAN, MOPT, ARESEP, SETENA) | 3d | 2023-06-14 A | 2023-06-16 A |  | 100% |  | start no earlier than 2023-06-14 |
| 12 |  | Entrega del Plan de Trabajo (honorario 1) | 1d | 2023-06-14 A | 2023-06-14 A |  | 100% |  | start no earlier than 2023-06-14 |
| 13 |  | Debida diligencia Legal | 97d | 2023-06-28 A | 2023-11-09 A | 6 | 100% |  | start no earlier than 2023-06-20 |
| 14 |  | Debida Diligencia Técnica, de Mercado y Análisis Tarifario | 109d | 2023-06-12 A | 2023-11-09 A | 4 | 100% |  | start no earlier than 2023-06-01 |
| 15 |  | Debida Diligencia Socio-Ambiental | 106d | 2023-06-15 A | 2023-11-09 A | 5 | 100% |  | start no earlier than 2023-06-06 |
| 16 |  | Debida Diligencia Financiera | 97d | 2023-06-19 A | 2023-10-31 A | 10 | 100% |  | start no earlier than 2023-06-19 |
| 17 |  | Sondeo de mercado | 10d | 2023-10-02 A | 2023-10-13 A |  | 100% |  | finish no earlier than 2023-10-13 |
| 18 |  | Plan de Comunicaciones | 98d | 2023-06-28 A | 2023-11-10 A | 7 | 100% |  | finish no earlier than 2023-10-31 |
| 19 |  | Entrega de los Estudios de Debida Diligencia Legal (Honorario 2 ) | 1d | 2023-11-10 A | 2023-11-10 A | 13 | 100% |  |  |
| 20 |  | Entrega de los estudios de Debida Diligencia Técnica y Socio-Ambiental (Honorario 3) | 1d | 2023-11-10 A | 2023-11-10 A | 14 | 100% |  |  |
| 21 |  | Preparación del Informe de Prefactibilidad | 13d | 2023-11-13 A | 2023-11-29 A | 20 | 100% |  | start no earlier than 2023-10-02 |
| 22 |  | Entrega del Informe de Prefactibilidad (Honorario 4) | 1d | 2023-11-30 A | 2023-11-30 A | 21 | 100% |  |  |
| 23 |  | Aprobación de INCOP del Informe de Prefactibilidad | 19d | 2024-01-04 A | 2024-01-30 A | 22 | 100% |  | finish no earlier than 2024-01-30 |
| 24 |  | Aprobación de la Secretaría de Planeación Sectorial del MOPT y de MIDEPLAN del Informe de Prefactibilidad | 65d | 2024-01-31 A | 2024-04-30 A | 23 | 100% |  | finish no earlier than 2024-04-30 |
| 25 |  | Preparación del Informe de Factibilidad | 58d | 2024-05-01 A | 2024-07-19 A | 24 | 100% |  |  |
| 26 |  | Entrega del Informe de Factibilidad (Honorario 5) | 1d | 2024-07-22 A | 2024-07-22 A | 25 | 100% |  |  |
| 27 |  | Aprobación de INCOP del Informe de Factibilidad | 32d | 2024-07-23 A | 2024-09-04 A | 26 | 100% |  |  |
| 28 |  | Aprobación de la Secretaría de Planeación Sectorial del MOPT y de MIDEPLAN del Informe de Factibilidad | 3d | 2024-09-05 A | 2024-09-09 A | 27 | 100% |  |  |
| 29 | 4.20 | **Proceso de Requerimientos Comision Evaluadora y Criterios de Admisibilidad** | 63d | 2024-01-31 A | 2024-04-26 |  | 59% | 597d |  |
| 30 |  | Redacción de Requerimientos de Legales, Técnicos y Financieros para Expresiones de Interés | 17d | 2024-01-31 A | 2024-02-22 A | 23 | 100% |  |  |
| 31 |  | Entrega de Requerimientos de Legales, Técnicos y Financieros (Honorario 6) | 1d | 2024-02-23 A | 2024-02-23 A | 30 | 100% |  |  |
| 32 |  | Aprobación de INCOP Criterios de Admisibilidad | 2d | 2024-02-26 A | 2024-02-27 A | 31 | 100% |  |  |
| 33 |  | Entrega de Requerimientos de Comision Evaluadora | 1d | 2024-02-23 A | 2024-02-23 A | 30 | 100% |  |  |
| 34 |  | Formación Comité Evaluador | 45d | 2024-02-26 | 2024-04-26 | 31 |  | 597d |  |
| 35 |  | Sondeo de Mercado con espectro de potenciales interesados | 45d | 2024-02-26 A | 2024-04-26 A | 31 | 100% |  |  |
| 36 | 4.21 | **Cartel de Licitación y Contrato de Concesión** | 195d | 2024-01-31 A | 2024-10-29 A |  | 100% |  |  |
| 37 |  | Redacción Cartel de Licitación y Contrato de Concesión | 136d | 2024-01-31 A | 2024-08-07 A | 23 | 100% |  |  |
| 38 |  | Entrega Cartel de Licitación y Contrato de Concesión (Honorario 7) | 1d | 2024-08-08 A | 2024-08-08 A | 37 | 100% |  |  |
| 39 | 4.21.3 | **Proceso de aprobacion para la publicación del Cartel de Licitación** | 57d | 2024-08-09 A | 2024-10-28 A | 38 | 100% |  |  |
| 40 |  | Aprobación por la junta directiva de INCOP | 57d | 2024-08-09 A | 2024-10-28 A | 38 | 100% |  |  |
| 41 |  | Aprobación de Ministerio de Ambiente sobre requerimientos de estudios ambientales en el Cartel | 1d | 2024-09-06 A | 2024-09-06 A | 40 | 100% |  |  |
| 42 |  | Aprobación de ARESEP de la estructura tarifaria y los parámetros de ajuste | 10d | 2024-08-30 A | 2024-09-12 A | 40 | 100% |  |  |
| 43 |  | Aprobación de Presidencia y MOPT del Cartel | 23d | 2024-09-13 A | 2024-10-15 A | 40, 42 | 100% |  |  |
| 44 |  | Preparación Sala de Datos y Requerimientos SICOP | 3d | 2024-10-25 A | 2024-10-29 A | 43 | 100% |  |  |
| 45 | 5 | **Fase 2 - Gestión de Contratación y Adjudicación** | 440d | 2024-10-30 A | 2026-07-07 | 39 | 18% | 25d |  |
| 46 |  | Publicación del Cartel de Licitación (notificación directa a cada uno de los oferentes precalificados) | 1d | 2024-10-30 A | 2024-10-30 A | 39, 44 | 100% |  |  |
| 47 |  | Recurso de objeción contra el cartel de la licitación (dentro del primer tercio del plazo para presentar ofertas) | 26d | 2024-10-31 A | 2024-12-05 A | 46 | 100% |  |  |
| 48 |  | Visita y Sesiones de Pre Oferta | 4d | 2024-11-25 A | 2024-11-28 A |  | 100% |  | start no earlier than 2024-11-25 |
| 49 |  | Respuesta de CGR por recurso de objeción | 33d | 2024-12-06 A | 2025-01-21 A | 47 | 100% |  |  |
| 50 |  | Periodo de solicitud de modificaciones y aclaraciones al Cartel | 68d | 2024-10-31 | 2025-02-03 | 46 |  | 396d |  |
| 51 |  | Redacción de solicitud criterio ARESEP por recurso de objeción | 14d | 2025-01-22 A | 2025-02-10 A | 49 | 100% |  |  |
| 52 |  | Solicitud criterio ARESEP por recurso objeción | 2d | 2025-02-10 A | 2025-02-11 A | 51 | 100% |  |  |
| 53 |  | Respuesta ARESEP Criterio | 10d | 2025-02-12 A | 2025-02-25 A | 52 | 100% |  |  |
| 54 |  | Redacción de modificaciones del cartel | 6d | 2025-02-26 A | 2025-03-05 A | 49, 50, 53 | 100% |  |  |
| 55 |  | Oficio Hacienda rectificacion Contingencias y VpD | 5d | 2025-03-06 A | 2025-03-12 A | 54 | 100% |  |  |
| 56 |  | Aprobación Junta Directiva modificaciones del cartel | 1d | 2025-03-13 A | 2025-03-13 A | 54, 55 | 100% |  |  |
| 57 |  | Publicación de cartel de licitación (post resolución CGR por recursos de objeción) | 2d | 2025-03-14 | 2025-03-17 | 56 |  | 0d |  |
| 58 |  | Periodo de recurso de objecion | 12d | 2025-03-18 | 2025-04-02 | 57 |  | 354d |  |
| 59 |  | Periodo de solicitud de modificaciones y aclaraciones al Cartel | 25d | 2025-03-18 | 2025-04-21 | 57 |  | 341d |  |
| 60 |  | Preparación de ofertas | 45d | 2025-03-18 | 2025-05-19 | 57 |  | 0d |  |
| 61 |  | Formalización de Comité Evaluador | 30d | 2025-01-22 | 2025-03-04 | 49 |  | 375d |  |
| 62 |  | Evaluación de Ofertas y dictámen de adjudicación (plazo de subsanación 5 días) | 45d | 2025-05-20 | 2025-07-21 | 60 |  | 0d |  |
| 63 |  | Apertura oferta económica | 1d | 2025-07-22 | 2025-07-22 | 62 |  | 275d |  |
| 64 |  | Informe de Recomendación de Oferta Adjudicada | 10d | 2025-07-22 | 2025-08-04 | 62 |  | 0d |  |
| 65 |  | Acto motivado de selección del adjudicatario | 10d | 2025-08-05 | 2025-08-18 | 64 |  | 0d |  |
| 66 |  | [Contingencia] por recurso de apelación contra acto de licitación | 5d | 2025-08-19 | 2025-08-25 | 65 |  | 0d |  |
| 67 |  | Aprobación de resolucion adjudicación por CGR | 45d | 2025-08-26 | 2025-10-27 | 66 |  | 0d |  |
| 68 |  | Adjudicación | 1d | 2025-10-28 | 2025-10-28 | 67 |  | 0d |  |
| 69 | 5.24 | **Formalización Contractual** | 60d | 2025-10-29 | 2026-01-20 | 68 |  | 0d |  |
| 70 |  | Constitución de la Sociedad Concesionaria | 45d | 2025-10-29 | 2025-12-30 | 68 |  | 0d |  |

| ID | WBS | Task | Duration | Start | Finish | Predecessors | Complete | Total float | Constraint |
| --- | --- | --- | --- | --- | --- | --- | --- | --- | --- |
| 71 |  | Cumplimiento de condiciones precedentes a la firma, formalización y suscripción | 14d | 2025-12-31 | 2026-01-19 | 70 |  | 0d |  |
| 72 |  | Firma, formalización y subscripción del Contrato de Concesión | 1d | 2026-01-20 | 2026-01-20 | 71 |  | 0d |  |
| 73 |  | Refrendo del Contrato de Concesión por CGR (Alcance del Contrato IFC) | 120d | 2026-01-21 | 2026-07-07 | 72 |  | 0d |  |
| 74 | 6 | **Prórroga Remolcadores** | 437d | 2024-04-02 A | 2025-12-03 |  | 8% | 179d |  |
| 75 |  | Analisis legal y tecnico del proceso de prorroga | 17d | 2024-04-02 A | 2024-04-24 A |  | 100% |  | start no earlier than 2024-04-02 |
| 76 |  | Acreditación del correspondiente interés público de la prórroga con sustento en estudios técnicos que así lo justifiquen | 21d | 2025-03-03 | 2025-03-31 |  |  | 179d | finish no earlier than 2025-03-31 |
| 77 |  | Solicitud de aprobación a Junta Directiva para iniciar el proceso de prórroga | 22d | 2025-04-01 | 2025-04-30 | 76 |  | 179d |  |
| 78 |  | Redacción de la respectiva adenda al Contrato | 43d | 2025-05-01 | 2025-06-30 | 77 |  | 179d |  |
| 79 |  | Formalización de la respectiva adenda al Contrato | 22d | 2025-07-01 | 2025-07-30 | 78 |  | 179d |  |
| 80 |  | Refrendo contralor de la adenda al contrato | 90d | 2025-07-31 | 2025-12-03 | 79 |  | 179d |  |
| 81 | 7 | **Protocolo de salida concesionario actual** | 394d? | 2025-01-01 | 2026-07-06 |  |  |  |  |
| 82 | 7.1 | **1. Inventario de activos** | 392d? | 2025-01-01 | 2026-07-02 |  |  | 0d |  |
| 83 | 7.1.1 | **Evaluar los equipos e infraestructura mediante diagnósticos semestrales, a partir del segundo semestre de 2024, continuando en 2025 y culminando en el primer trimestre de 2026.** | 323d | 2025-01-01 | 2026-03-27 |  |  |  |  |
| 84 |  | Diagnóstico junio 2025 | 129d | 2025-01-01 | 2025-06-30 |  |  | 27d |  |
| 85 |  | Diagnóstico diciembre 2025 | 124d | 2025-07-01 | 2025-12-19 | 84 |  | 27d |  |
| 86 |  | Diagnóstico marzo 2026 | 70d | 2025-12-22 | 2026-03-27 | 85 |  | 27d |  |
| 87 | 7.1.2 | **Inventario final** | 131d? | 2025-09-30 | 2026-03-31 |  |  |  |  |
| 88 |  | Contratación consultor para realizar inventario final y recepcion de bienes | 40d | 2025-09-30 | 2025-11-24 |  |  | 3d |  |
| 89 |  | Realizar inventario final | 90d | 2025-11-25 | 2026-03-30 | 88 |  | 3d |  |
| 90 |  | Entrega de inventario final por parte del consultor de INCOP | 1d | 2026-03-31 | 2026-03-31 | 89 |  | 3d |  |
| 91 |  | INCOP revisión de entrega | 22d | 2026-04-01 | 2026-04-30 | 90 |  | 3d |  |
| 92 |  | Redacción del borrador finiquito y acta de recepción de todos los activos según el inventario | 45d | 2026-05-01 | 2026-07-02 | 83, 91 |  | 3d | finish no earlier than 2026-05-29 |
| 93 | 7.2 | **2. Contratos laborales y de subcontratistas** | 282d | 2025-03-03 | 2026-03-31 |  |  | 70d |  |
| 94 |  | INCOP solicitar al concesionario actual el listado de subcontrataciones, proveedores y contratos con terceros vigentes con montos vigentes | 66d | 2025-03-03 | 2025-06-02 |  |  | 70d | start no earlier than 2025-03-03 |
| 95 |  | Concesionario actual entregar el listado de subcontrataciones, proveedores y terceros vigentes con montos y terminos vigentes certificado por un auditor externo | 86d | 2025-06-03 | 2025-09-30 | 94 |  | 70d |  |
| 96 |  | INCOP revisión de entrega | 45d | 2025-10-01 | 2025-12-02 | 95 |  | 70d |  |
| 97 |  | Redacción del borrador del finiquito de todos los contratos con terceros y subcontratistas | 85d | 2025-12-03 | 2026-03-31 | 96 |  | 70d |  |
| 98 | 7.3 | **3. Listado de licencias y permisos** | 325d | 2025-03-03 | 2026-05-29 |  |  | 27d |  |
| 99 |  | El INCOP deberá solicitar al concesionario actual un listado de las licencias y permisos vigentes | 66d | 2025-03-03 | 2025-06-02 |  |  | 70d | start no earlier than 2025-03-03 |
| 100 |  | Concesionario actual entrega un listado de las licencias y permisos vigentes certificado por un auditor externo | 86d | 2025-06-03 | 2025-09-30 | 99 |  | 70d |  |
| 101 |  | INCOP revisión entrega | 45d | 2025-10-01 | 2025-12-02 | 100 |  | 70d |  |
| 102 |  | Redacción del finiquito de dichos permisos, licencias y autorizaciones certificado | 85d | 2026-02-02 | 2026-05-29 | 101 |  | 27d | finish no earlier than 2026-05-29 |
| 103 | 7.4 | **4. Servicios públicos** | 325d | 2025-03-03 | 2026-05-29 |  |  | 27d | start no earlier than 2025-01-01 |
| 104 |  | El INCOP deberá solicitar al concesionario actual un inventario de los servicios públicos son sus respectivos contratos, facturas, montos vigentes | 66d | 2025-03-03 | 2025-06-02 |  |  | 70d | start no earlier than 2025-03-03 |
| 105 |  | El concesionario deberá entregar un inventario de los servicios públicos son sus respectivos contratos, facturas, montos vigentes certificado por un auditor externo | 86d | 2025-06-03 | 2025-09-30 | 104 |  | 70d | start no earlier than 2025-03-03 |
| 106 |  | INCOP revisión entrega | 45d | 2025-10-01 | 2025-12-02 | 105 |  | 70d |  |
| 107 |  | Se deberá redactar el finiquito de dichos servicios que apliquen | 85d | 2026-02-02 | 2026-05-29 | 106 |  | 27d | finish no earlier than 2026-05-29 |
| 108 | 7.5 | **5. Canon** | 392d | 2025-01-02 | 2026-07-03 |  |  | 0d |  |
| 109 |  | Entrega de comprobante de pago de canon conforme facturas recibidas certificadas por un auditor externo | 389d | 2025-01-02 | 2026-06-30 |  |  |  |  |
| 110 |  | Monitoreo de pago de canon conforme facturas recibidas certificadas por un auditor externo | 389d | 2025-01-02 | 2026-06-30 |  |  | 2d | finish no earlier than 2026-06-30 |
| 111 |  | Redacción de finiquito borrador de que no hay saldo pendiente del pago de canon a INCOP | 3d | 2026-07-01 | 2026-07-03 | 109, 110 |  | 2d | start no earlier than 2026-02-17 |
| 112 | 7.6 | **6. Financiero** | 395d | 2025-01-01 | 2026-07-07 |  |  | 0d |  |
| 113 |  | Entrega de información financiera y modelo financiero actualizado trimestral y anual | 390d | 2025-01-01 | 2026-06-30 |  |  | 0d |  |
| 114 |  | Revisión de información financiera actualizada y modelo financiero trimestral y anual | 390d | 2025-01-01 | 2026-06-30 |  |  | 0d |  |
| 115 |  | INCOP presupuestar y contratar a una firma auditora para que apoye en la revisión del modelo | 30d | 2025-12-01 | 2026-01-09 |  |  | 32d | start no earlier than 2025-12-01 |
| 116 |  | Revisión demodelo por firma de auditoría | 120d | 2026-01-12 | 2026-06-26 | 115 |  | 32d |  |
| 117 |  | Entrega de modelo financiero actualizado para versión final | 3d | 2026-07-01 | 2026-07-03 | 113, 114 |  | 27d |  |
| 118 |  | Finiquito borrador de que no existe ninguna obligación de compensación adicional por parte de los concesionarios actuales y el INCOP | 5d | 2026-07-01 | 2026-07-07 | 113, 114 |  | 0d |  |
| 119 | 7.7 | **7. Ambiental y Social** | 317d | 2025-03-03 | 2026-05-19 |  |  | 35d |  |
| 120 |  | El INCOP deberá solicitar al concesionario actual un inventario de los permisos ambientales | 66d | 2025-03-03 | 2025-06-02 |  |  | 35d | start no earlier than 2025-03-03 |
| 121 |  | Entrega de inventario de los permisos ambientales | 86d | 2025-06-03 | 2025-09-30 | 120 |  |  |  |
| 122 |  | INCOP revisión entrega | 45d | 2025-10-01 | 2025-12-02 | 121 |  | 70d |  |
| 123 |  | Se deberá redactar finiquito de dichos permisos que apliquen | 85d | 2025-12-03 | 2026-03-31 | 122 |  | 70d |  |
| 124 |  | Acercamiento SETENA para evaluar cierre de garantía ambiental | 45d | 2025-10-01 | 2025-12-02 | 121 |  | 35d |  |
| 125 |  | Borrador para cierre de garantía ambiental del concesionario actual | 120d | 2025-12-03 | 2026-05-19 | 124 |  | 35d |  |
| 126 | 7.8 | **8. Garantías y seguros** | 282d | 2025-03-03 | 2026-03-31 |  |  | 70d |  |
| 127 |  | El INCOP deberá solicitar al concesionario actual un inventario de los seguros y garantías | 66d | 2025-03-03 | 2025-06-02 |  |  | 70d | start no earlier than 2025-03-03 |
| 128 |  | Entrega inventario seguros y garantias | 86d | 2025-06-03 | 2025-09-30 | 127 |  | 70d |  |
| 129 |  | INCOP revisión entrega | 45d | 2025-10-01 | 2025-12-02 | 128 |  | 70d |  |
| 130 |  | Borrador para finiquito de cierre de garantías y seguros | 85d | 2025-12-03 | 2026-03-31 | 129 |  | 70d |  |
| 131 | 7.9 | **9. Operativos** | 282d | 2025-03-03 | 2026-03-31 |  |  | 70d |  |
| 132 |  | El INCOP deberá solicitar al concesionario actual los manuales, garantías de equipo e informes de mantenimiento de los equipamientos y en su caso realizar las actualizaciones necesarias | 66d | 2025-03-03 | 2025-06-02 |  |  | 70d | start no earlier than 2025-03-03 |
| 133 |  | Entrega de los manuales, garantías de equipo e informes de mantenimiento de los equipamientos | 86d | 2025-06-03 | 2025-09-30 | 132 |  | 70d |  |
| 134 |  | INCOP revisión entrega | 45d | 2025-10-01 | 2025-12-02 | 133 |  | 70d |  |
| 135 |  | Borrador finiquito que no hay entrega pendientes de manuales, garantías de equipo e informes de mantenimiento | 85d | 2025-12-03 | 2026-03-31 | 134 |  | 70d |  |
| 136 | 7.10 | **10. Documentación referente a la infraestructura existente** | 282d | 2025-03-03 | 2026-03-31 |  |  | 70d |  |
| 137 |  | El INCOP deberá solicitar información de los planos finales "As built" | 66d | 2025-03-03 | 2025-06-02 |  |  | 70d | start no earlier than 2025-03-03 |
| 138 |  | Entrega de los planos | 86d | 2025-06-03 | 2025-09-30 | 137 |  | 70d |  |
| 139 |  | INCOP revisión de entrega | 45d | 2025-10-01 | 2025-12-02 | 138 |  | 70d |  |
| 140 |  | Borrador finiquito que no hay entrega pendiente de informacion | 85d | 2025-12-03 | 2026-03-31 | 139 |  | 70d |  |

| ID | WBS | Task | Duration | Start | Finish | Predecessors | Total float |
| --- | --- | --- | --- | --- | --- | --- | --- |
| 141 | 8 | **Etapa de Transición Inicial del Contrato de Concesión** | 25d | 2026-07-08 | 2026-08-11 | 73 | 0d |
| 142 |  | Formalización y Entrega Finiquito de las concesiones previas de los concesionarios previos | 24d | 2026-07-08 | 2026-08-10 | 73, 92, 97, 111, 118, 135, 140 | 0d |
| 143 |  | Culminar el cierre y apertura de permisos y servicios públicos al nuevo concesionario | 24d | 2026-07-08 | 2026-08-10 | 73, 102, 107, 123 | 0d |
| 144 |  | Cierre y apertura de garantías | 24d | 2026-07-08 | 2026-08-10 | 125, 130 | 0d |
| 145 |  | Redacción orden de inicio y acta de inicio de la concesión | 24d | 2026-07-08 | 2026-08-10 | 73 | 0d |
| 146 |  | Formalización del Acta de recepción de las Concesiones Previas | 1d | 2026-08-11 | 2026-08-11 | 142, 143, 144, 145 | 0d |
| 147 |  | Orden de Inicio y Acta de Inicio de la Concesión | 1d | 2026-08-11 | 2026-08-11 | 146SS | 0d |

## Version 2 (saved 2025-05-12, file Puerto_Caldera_IFC_INCOP v9.mpp)

Last finish stays 2026-08-11. Complete tasks 48 → 52.

Added:

| ID | Task | Duration | Start | Finish | Predecessors | Constraint | Resources |
| --- | --- | --- | --- | --- | --- | --- | --- |
| 59 | Segundo recurso de objecion (DP World) | 1d | 2025-04-04 A | 2025-04-04 A |  | start no earlier than 2025-04-04 | Proponentes |
| 60 | Notificación del tercer recurso de objeción | 1d | 2025-04-30 A | 2025-04-30 A |  | start no earlier than 2025-04-30 | Proponentes |
| 61 | Respuesta CGR 2 y 3 recurso de objeción (24 de mayo pero por ser sabado se marca como 23) | 17d | 2025-05-01 | 2025-05-23 | 60 |  | Contraloría |
| 62 | Post resolución CGR por 2 y 3 recurso de objeción | 5d | 2025-05-26 | 2025-05-30 | 61 |  | INCOP; IFC |

Removed: 58 Periodo de recurso de objecion

Changed:

| ID | Task | Start | Finish | Duration | Complete | Total float | Predecessors | Other |
| --- | --- | --- | --- | --- | --- | --- | --- | --- |
| 45 | **Fase 2 - Gestión de Contratación y Adjudicación** |  | 2026-07-07 → 2026-06-22 (-15d) | 440d → 429d | 18% → 25% | 25d → 36d |  |  |
| 57 | Publicación de cartel de licitación (post resolución CGR por recursos de objeción) | 2025-03-14 A | 2025-03-17 A |  | 0% → 100% | 0d → none |  |  |
| 58 | Periodo de solicitud de modificaciones y aclaraciones al Cartel | 2025-03-18 A | 2025-04-21 A |  | 0% → 100% | 341d → none |  |  |
| 63 | Preparación de ofertas | 2025-03-18 → 2025-06-02 (+76d) | 2025-05-19 → 2025-06-06 (+18d) | 45d → 5d |  | 0d → 11d | 57 → 62 | resources none → Proponentes |
| 65 | Evaluación de Ofertas y dictámen de adjudicación | 2025-05-20 → 2025-06-09 (+20d) | 2025-07-21 → 2025-08-08 (+18d) |  |  | 0d → 11d |  | was named Evaluación de Ofertas y dictámen de adjudicación (plazo de subsanación 5 días) |
| 66 | Apertura oferta económica | 2025-07-22 → 2025-08-11 (+20d) | 2025-07-22 → 2025-08-11 (+20d) |  |  | 275d → 261d |  |  |
| 67 | Informe de Recomendación de Oferta Adjudicada | 2025-07-22 → 2025-08-11 (+20d) | 2025-08-04 → 2025-08-22 (+18d) |  |  | 0d → 11d |  |  |
| 68 | Acto motivado de selección del adjudicatario | 2025-08-05 → 2025-08-25 (+20d) | 2025-08-18 → 2025-09-05 (+18d) |  |  | 0d → 11d |  |  |
| 69 | [Contingencia] por recurso de apelación contra acto de licitación | 2025-08-19 → 2025-09-08 (+20d) | 2025-08-25 → 2025-09-19 (+25d) | 5d → 10d |  | 0d → 11d |  |  |
| 70 | Aprobación de resolucion adjudicación por CGR | 2025-08-26 → 2025-09-22 (+27d) | 2025-10-27 → 2025-11-14 (+18d) | 45d → 40d |  | 0d → 11d |  |  |
| 71 | Adjudicación | 2025-10-28 → 2025-11-17 (+20d) | 2025-10-28 → 2025-11-17 (+20d) |  |  | 0d → 11d |  |  |
| 72 | **Formalización Contractual** | 2025-10-29 → 2025-11-18 (+20d) | 2026-01-20 → 2026-02-09 (+20d) |  |  | 0d → 11d |  |  |
| 73 | Constitución de la Sociedad Concesionaria | 2025-10-29 → 2025-11-18 (+20d) | 2025-12-30 → 2026-01-19 (+20d) |  |  | 0d → 11d |  |  |
| 74 | Cumplimiento de condiciones precedentes a la firma, formalización y suscripción | 2025-12-31 → 2026-01-20 (+20d) | 2026-01-19 → 2026-02-06 (+18d) |  |  | 0d → 11d |  |  |
| 75 | Firma, formalización y subscripción del Contrato de Concesión | 2026-01-20 → 2026-02-09 (+20d) | 2026-01-20 → 2026-02-09 (+20d) |  |  | 0d → 11d |  |  |
| 76 | Refrendo del Contrato de Concesión por CGR (Alcance del Contrato IFC) | 2026-01-21 → 2026-02-10 (+20d) | 2026-07-07 → 2026-06-22 (-15d) | 120d → 95d |  | 0d → 11d |  |  |
| 144 | **Etapa de Transición Inicial del Contrato de Concesión** | 2026-07-08 → 2026-06-23 (-15d) |  | 25d → 36d |  |  |  |  |
| 146 | Culminar el cierre y apertura de permisos y servicios públicos al nuevo concesionario | 2026-07-08 → 2026-06-23 (-15d) | 2026-08-10 → 2026-07-24 (-17d) |  |  | 0d → 11d |  |  |
| 147 | Cierre y apertura de garantías | 2026-07-08 → 2026-06-23 (-15d) | 2026-08-10 → 2026-07-24 (-17d) |  |  | 0d → 11d |  |  |
| 148 | Redacción orden de inicio y acta de inicio de la concesión | 2026-07-08 → 2026-06-23 (-15d) | 2026-08-10 → 2026-07-24 (-17d) |  |  | 0d → 11d |  |  |

## Version 3 (saved 2025-06-12, file Puerto_Caldera_IFC_INCOP v10.mpp)

Last finish stays 2026-08-11.

Changed:

| ID | Task | Start | Finish | Duration | Complete | Total float | Other |
| --- | --- | --- | --- | --- | --- | --- | --- |
| 45 | **Fase 2 - Gestión de Contratación y Adjudicación** |  | 2026-06-22 → 2026-08-06 (+45d) | 429d → 462d | 25% → 23% | 36d → 3d |  |
| 60 | Tercer recurso de objecion |  |  |  |  |  | was named Notificación del tercer recurso de objeción |
| 61 | Respuesta CGR 2 y 3 recurso de objecion |  |  |  |  | 11d → 0d | was named Respuesta CGR 2 y 3 recurso de objeción (24 de mayo pero por ser sabado se marca como 23) |
| 62 | Publicación de cartel de licitación (post resolución CGR por 2 y 3 recurso de objeción) |  | 2025-05-30 → 2025-06-24 (+25d) | 5d → 22d |  | 11d → 0d | was named Post resolución CGR por 2 y 3 recurso de objeción |
| 63 | Preparación de ofertas | 2025-06-02 → 2025-06-25 (+23d) | 2025-06-06 → 2025-07-16 (+40d) | 5d → 16d |  | 11d → 0d |  |
| 65 | Evaluación de Ofertas y dictámen de adjudicación (plazo de subsanación 5 días) | 2025-06-09 → 2025-07-17 (+38d) | 2025-08-08 → 2025-09-17 (+40d) |  |  | 11d → 0d | was named Evaluación de Ofertas y dictámen de adjudicación |
| 66 | Apertura oferta económica | 2025-08-11 → 2025-09-18 (+38d) | 2025-08-11 → 2025-09-18 (+38d) |  |  | 261d → 233d |  |
| 67 | Informe de Recomendación de Oferta Adjudicada | 2025-08-11 → 2025-09-18 (+38d) | 2025-08-22 → 2025-10-01 (+40d) |  |  | 11d → 0d |  |
| 68 | Acto motivado de selección del adjudicatario | 2025-08-25 → 2025-10-02 (+38d) | 2025-09-05 → 2025-10-15 (+40d) |  |  | 11d → 0d |  |
| 69 | [Contingencia] por recurso de apelación contra acto de licitación | 2025-09-08 → 2025-10-16 (+38d) | 2025-09-19 → 2025-10-29 (+40d) |  |  | 11d → 0d |  |
| 70 | Aprobación de resolucion adjudicación por CGR | 2025-09-22 → 2025-10-30 (+38d) | 2025-11-14 → 2025-11-26 (+12d) | 40d → 20d |  | 11d → 0d |  |
| 71 | Adjudicación | 2025-11-17 → 2025-11-27 (+10d) | 2025-11-17 → 2025-11-27 (+10d) |  |  | 11d → 0d |  |
| 72 | **Formalización Contractual** | 2025-11-18 → 2025-11-28 (+10d) | 2026-02-09 → 2026-02-19 (+10d) |  |  | 11d → 0d |  |
| 73 | Constitución de la Sociedad Concesionaria | 2025-11-18 → 2025-11-28 (+10d) | 2026-01-19 → 2026-01-29 (+10d) |  |  | 11d → 0d |  |
| 74 | Cumplimiento de condiciones precedentes a la firma, formalización y suscripción | 2026-01-20 → 2026-01-30 (+10d) | 2026-02-06 → 2026-02-18 (+12d) |  |  | 11d → 0d |  |
| 75 | Firma, formalización y subscripción del Contrato de Concesión | 2026-02-09 → 2026-02-19 (+10d) | 2026-02-09 → 2026-02-19 (+10d) |  |  | 11d → 0d |  |
| 76 | Refrendo del Contrato de Concesión por CGR (Alcance del Contrato IFC) | 2026-02-10 → 2026-02-20 (+10d) | 2026-06-22 → 2026-08-06 (+45d) | 95d → 120d |  | 11d → 0d |  |
| 144 | **Etapa de Transición Inicial del Contrato de Concesión** | 2026-06-23 → 2026-08-07 (+45d) |  | 36d → 3d |  |  |  |
| 145 | Formalización y Entrega Finiquito de las concesiones previas de los concesionarios previos | 2026-07-08 → 2026-08-07 (+30d) |  | 24d → 2d |  |  |  |
| 146 | Culminar el cierre y apertura de permisos y servicios públicos al nuevo concesionario | 2026-06-23 → 2026-08-07 (+45d) | 2026-07-24 → 2026-08-10 (+17d) | 24d → 2d |  | 11d → 0d |  |
| 147 | Cierre y apertura de garantías | 2026-06-23 → 2026-08-07 (+45d) | 2026-07-24 → 2026-08-10 (+17d) | 24d → 2d |  | 11d → 0d |  |
| 148 | Redacción orden de inicio y acta de inicio de la concesión | 2026-06-23 → 2026-08-07 (+45d) | 2026-07-24 → 2026-08-10 (+17d) | 24d → 2d |  | 11d → 0d |  |

## Version 4 (saved 2026-02-18, file Puerto_Caldera_IFC_INCOP v11.mpp)

Last finish stays 2026-08-11. Complete tasks 52 → 67.

Added:

| ID | Task | Duration | Start | Finish | Predecessors | Resources |
| --- | --- | --- | --- | --- | --- | --- |
| 63 | Cuarto recurso de objecion | 6d | 2025-06-25 A | 2025-07-02 A | 62 | Proponentes |
| 64 | Respuesta CGR a 4 Recurso de objecion | 22d | 2024-10-30 A | 2025-07-31 A | 63 | Contraloría |
| 65 | Redacción de modificaciones del cartel | 35d | 2025-08-01 A | 2025-09-18 A | 64 | IFC; INCOP |
| 66 | Oficio Hacienda rectificacion Contingencias y VpD y Consulta ARESEP | 15d | 2025-08-01 A | 2025-08-21 A | 64 | ARESEP; Hacienda; INCOP |
| 67 | Aprobación Junta Directiva modificaciones del cartel | 1d | 2025-09-19 A | 2025-09-19 A | 65 | INCOP |
| 68 | Publicación de cartel de licitación (post resolución CGR por recursos de objeción) | 2d | 2025-09-22 A | 2025-09-23 A | 67 | INCOP |
| 75 | Publicacion Gaceta | 2d | 2026-03-19 | 2026-03-20 | 74 |  |

Changed:

| ID | Task | Start | Finish | Duration | Complete | Total float | Predecessors | Other |
| --- | --- | --- | --- | --- | --- | --- | --- | --- |
| 45 | **Fase 2 - Gestión de Contratación y Adjudicación** |  | 2026-08-06 → 2026-07-29 (-8d) | 462d → 440d | 23% → 61% | 3d → 9d |  |  |
| 61 | Respuesta CGR 2 y 3 recurso de objecion | 2025-05-01 A | 2025-05-23 A |  | 0% → 100% | 0d → none |  |  |
| 62 | Publicación de cartel de licitación (post resolución CGR por 2 y 3 recurso de objeción) | 2025-05-26 A | 2025-06-24 A |  | 0% → 100% | 0d → none |  |  |
| 69 | Preparación y presentacion de ofertas | 2025-06-25 → 2025-09-24 (+91d) | 2025-07-16 → 2025-11-07 (+114d) | 16d → 33d |  | 0d → 181d | 62 → 68 | was named Preparación de ofertas |
| 70 | Formalización de Comité Evaluador | 2025-01-22 A | 2025-03-04 A |  | 0% → 100% | 375d → none |  |  |
| 71 | Evaluación de Ofertas y dictámen de adjudicación | 2025-07-17 → 2025-11-10 A (+116d) | 2025-09-17 → 2026-02-13 A (+149d) | 45d → 54d | 0% → 100% | 0d → none |  | was named Evaluación de Ofertas y dictámen de adjudicación (plazo de subsanación 5 días) |
| 72 | Apertura oferta económica | 2025-09-18 → 2026-02-16 A (+151d) | 2025-09-18 → 2026-02-18 A (+153d) | 1d → 3d | 0% → 100% | 233d → none |  |  |
| 73 | Informe de Recomendación de Oferta Adjudicada | 2025-09-18 → 2026-02-19 (+154d) | 2025-10-01 → 2026-03-04 (+154d) |  |  |  | 71 → 71, 72 |  |
| 74 | Acto motivado de selección del adjudicatario | 2025-10-02 → 2026-03-05 (+154d) | 2025-10-15 → 2026-03-18 (+154d) |  |  |  |  |  |
| 76 | [Contingencia] por recurso de apelación contra acto de licitación | 2025-10-16 → 2026-03-23 (+158d) | 2025-10-29 → 2026-04-03 (+156d) |  |  |  | 74 → 74, 75 |  |
| 77 | Aprobación de resolucion adjudicación por CGR | 2025-10-30 → 2026-04-06 (+158d) | 2025-11-26 → 2026-05-15 (+170d) | 20d → 30d |  |  |  |  |
| 78 | Adjudicación | 2025-11-27 → 2026-05-18 (+172d) | 2025-11-27 → 2026-05-18 (+172d) |  |  |  |  |  |
| 79 | **Formalización Contractual** | 2025-11-28 → 2026-05-19 (+172d) | 2026-02-19 → 2026-06-17 (+118d) | 60d → 22d |  |  |  |  |
| 80 | Constitución de la Sociedad Concesionaria | 2025-11-28 → 2026-05-19 (+172d) | 2026-01-29 → 2026-06-09 (+131d) | 45d → 16d |  |  |  |  |
| 81 | Cumplimiento de condiciones precedentes a la firma, formalización y suscripción | 2026-01-30 → 2026-06-10 (+131d) | 2026-02-18 → 2026-06-16 (+118d) | 14d → 5d |  |  |  |  |
| 82 | Firma, formalización y subscripción del Contrato de Concesión | 2026-02-19 → 2026-06-17 (+118d) | 2026-02-19 → 2026-06-17 (+118d) |  |  |  |  |  |
| 83 | Refrendo del Contrato de Concesión por CGR | 2026-02-20 → 2026-06-18 (+118d) | 2026-08-06 → 2026-07-29 (-8d) | 120d → 30d |  |  |  | was named Refrendo del Contrato de Concesión por CGR (Alcance del Contrato IFC) |
| 84 | **Prórroga Remolcadores** |  | 2025-12-03 → 2025-12-05 (+2d) | 437d → 439d | 8% → 92% | 179d → 161d |  |  |
| 86 | Acreditación del correspondiente interés público de la prórroga con sustento en estudios técnicos que así lo justifiquen | 2025-03-03 A | 2025-03-31 A |  | 0% → 100% | 179d → none |  |  |
| 87 | Solicitud de aprobación a Junta Directiva para iniciar el proceso de prórroga | 2025-04-01 A | 2025-04-30 A |  | 0% → 100% | 179d → none |  |  |
| 88 | Redacción de la respectiva adenda al Contrato | 2025-05-01 A | 2025-06-30 → 2025-09-03 A (+65d) | 43d → 90d | 0% → 100% | 179d → none |  |  |
| 89 | Formalización de la respectiva adenda al Contrato | 2025-07-01 → 2025-09-04 A (+65d) | 2025-07-30 → 2025-10-15 A (+77d) | 22d → 30d | 0% → 100% | 179d → none |  |  |
| 90 | Refrendo interno de la adenda al contrato y orden de inicio | 2025-07-31 → 2025-10-09 A (+70d) | 2025-12-03 → 2025-12-05 (+2d) | 90d → 42d | 0% → 60% | 179d → 161d |  | was named Refrendo contralor de la adenda al contrato |
| 91 | **Protocolo de salida concesionario actual** |  |  | 394d? → 378d? |  |  |  |  |
| 92 | **1. Inventario de activos** |  | 2026-07-02 → 2026-07-24 (+22d) |  |  |  |  |  |
| 93 | **Evaluar los equipos e infraestructura mediante diagnósticos semestrales, a partir del segundo semestre de 2024, continuando en 2025 y culminando en el primer trimestre de 2026.** |  |  | 323d → 307d |  |  |  |  |
| 96 | Diagnóstico marzo 2026 |  | 2026-03-27 → 2026-04-20 (+24d) |  |  | 49d → 30d |  |  |
| 97 | **Inventario final** |  |  | 131d? → 115d? |  |  |  |  |
| 99 | Realizar inventario final |  | 2026-03-30 → 2026-04-21 (+22d) |  |  | 25d → 6d |  |  |
| 100 | Entrega de inventario final por parte del consultor de INCOP | 2026-03-31 → 2026-04-22 (+22d) | 2026-03-31 → 2026-04-22 (+22d) |  |  | 25d → 6d |  |  |
| 101 | INCOP revisión de entrega | 2026-04-01 → 2026-04-23 (+22d) | 2026-04-30 → 2026-05-22 (+22d) |  |  | 25d → 6d |  |  |
| 102 | Redacción del borrador finiquito y acta de recepción de todos los activos según el inventario | 2026-05-01 → 2026-05-25 (+24d) | 2026-07-02 → 2026-07-24 (+22d) |  |  | 25d → 6d |  |  |
| 103 | **2. Contratos laborales y de subcontratistas** |  | 2026-03-31 → 2026-06-24 (+85d) | 282d → 327d |  | 92d → 28d |  |  |
| 106 | INCOP revisión de entrega |  | 2025-12-02 → 2026-02-25 (+85d) | 45d → 90d |  | 92d → 28d |  |  |
| 107 | Redacción del borrador del finiquito de todos los contratos con terceros y subcontratistas | 2025-12-03 → 2026-02-26 (+85d) | 2026-03-31 → 2026-06-24 (+85d) |  |  | 92d → 28d |  |  |
| 108 | **3. Listado de licencias y permisos** |  | 2026-05-29 → 2026-06-24 (+26d) | 325d → 327d |  | 49d → 31d |  |  |
| 111 | INCOP revisión entrega |  | 2025-12-02 → 2026-02-25 (+85d) | 45d → 90d |  | 92d → 31d |  |  |
| 112 | Redacción del finiquito de dichos permisos, licencias y autorizaciones certificado | 2026-02-02 → 2026-02-26 (+24d) | 2026-05-29 → 2026-06-24 (+26d) |  |  | 49d → 31d |  |  |
| 113 | **4. Servicios públicos** |  | 2026-05-29 → 2026-06-24 (+26d) | 325d → 327d |  | 49d → 31d |  |  |
| 116 | INCOP revisión entrega |  | 2025-12-02 → 2026-02-25 (+85d) | 45d → 90d |  | 92d → 31d |  |  |
| 117 | Se deberá redactar el finiquito de dichos servicios que apliquen | 2026-02-02 → 2026-02-26 (+24d) | 2026-05-29 → 2026-06-24 (+26d) |  |  | 49d → 31d |  |  |
| 118 | **5. Canon** | 2025-01-02 → 2025-01-01 (-1d) | 2026-07-03 → 2026-07-27 (+24d) | 392d → 393d |  | 0d → 1d |  |  |
| 119 | Entrega de comprobante de pago de canon conforme facturas recibidas certificadas por un auditor externo |  | 2026-06-30 → 2026-07-22 (+22d) |  |  |  |  |  |
| 120 | Monitoreo de pago de canon conforme facturas recibidas certificadas por un auditor externo | 2025-01-02 → 2025-01-01 (-1d) | 2026-06-30 → 2026-07-21 (+21d) |  |  | 24d → 6d |  |  |
| 121 | Redacción de finiquito borrador de que no hay saldo pendiente del pago de canon a INCOP | 2026-07-01 → 2026-07-23 (+22d) | 2026-07-03 → 2026-07-27 (+24d) |  |  | 24d → 5d |  |  |
| 122 | **6. Financiero** |  | 2026-07-07 → 2026-07-29 (+22d) |  |  | 22d → 3d |  |  |
| 123 | Entrega de información financiera y modelo financiero actualizado trimestral y anual |  | 2026-06-30 → 2026-07-22 (+22d) |  |  | 22d → 3d |  |  |
| 124 | Revisión de información financiera actualizada y modelo financiero trimestral y anual |  | 2026-06-30 → 2026-07-22 (+22d) |  |  | 22d → 3d |  |  |
| 125 | INCOP presupuestar y contratar a una firma auditora para que apoye en la revisión del modelo |  | 2026-01-09 → 2026-02-02 (+24d) |  |  | 32d → 16d |  |  |
| 126 | Revisión demodelo por firma de auditoría | 2026-01-12 → 2026-02-03 (+22d) | 2026-06-26 → 2026-07-20 (+24d) |  |  | 32d → 16d |  |  |
| 127 | Entrega de modelo financiero actualizado para versión final | 2026-07-01 → 2026-07-23 (+22d) | 2026-07-03 → 2026-07-27 (+24d) |  |  | 27d → 11d |  |  |
| 128 | Finiquito borrador de que no existe ninguna obligación de compensación adicional por parte de los concesionarios actuales y el INCOP | 2026-07-01 → 2026-07-23 (+22d) | 2026-07-07 → 2026-07-29 (+22d) |  |  | 22d → 3d |  |  |
| 129 | **7. Ambiental y Social** |  | 2026-05-19 → 2026-07-15 (+57d) | 317d → 342d |  | 57d → 16d |  |  |
| 133 | Se deberá redactar finiquito de dichos permisos que apliquen |  | 2026-03-31 → 2026-04-22 (+22d) |  |  | 92d → 76d |  |  |
| 134 | Acercamiento SETENA para evaluar cierre de garantía ambiental |  | 2025-12-02 → 2026-02-25 (+85d) | 45d → 90d |  | 57d → 16d |  |  |
| 135 | Borrador para cierre de garantía ambiental del concesionario actual | 2025-12-03 → 2026-02-26 (+85d) | 2026-05-19 → 2026-07-15 (+57d) | 120d → 100d |  | 57d → 16d |  |  |
| 136 | **8. Garantías y seguros** |  | 2026-03-31 → 2026-04-22 (+22d) |  |  | 92d → 76d |  |  |
| 140 | Borrador para finiquito de cierre de garantías y seguros |  | 2026-03-31 → 2026-04-22 (+22d) |  |  | 92d → 76d |  |  |
| 141 | **9. Operativos** |  | 2026-03-31 → 2026-06-24 (+85d) | 282d → 327d |  | 92d → 28d |  |  |
| 144 | INCOP revisión entrega |  | 2025-12-02 → 2026-02-25 (+85d) | 45d → 90d |  | 92d → 28d |  |  |
| 145 | Borrador finiquito que no hay entrega pendientes de manuales, garantías de equipo e informes de mantenimiento | 2025-12-03 → 2026-02-26 (+85d) | 2026-03-31 → 2026-06-24 (+85d) |  |  | 92d → 28d |  |  |
| 146 | **10. Documentación referente a la infraestructura existente** |  | 2026-03-31 → 2026-04-22 (+22d) |  |  | 92d → 73d |  |  |
| 150 | Borrador finiquito que no hay entrega pendiente de informacion |  | 2026-03-31 → 2026-04-22 (+22d) |  |  | 92d → 73d |  |  |
| 151 | **Etapa de Transición Inicial del Contrato de Concesión** | 2026-08-07 → 2026-07-30 (-8d) |  | 3d → 9d |  |  |  |  |
| 152 | Formalización y Entrega Finiquito de las concesiones previas de los concesionarios previos | 2026-08-07 → 2026-07-30 (-8d) | 2026-08-10 → 2026-08-05 (-5d) | 2d → 5d |  | 0d → 3d |  |  |
| 153 | Culminar el cierre y apertura de permisos y servicios públicos al nuevo concesionario | 2026-08-07 → 2026-07-30 (-8d) | 2026-08-10 → 2026-07-31 (-10d) |  |  | 0d → 6d |  |  |
| 154 | Cierre y apertura de garantías | 2026-08-07 → 2026-07-30 (-8d) | 2026-08-10 → 2026-07-31 (-10d) |  |  | 0d → 6d |  |  |
| 155 | Redacción orden de inicio y acta de inicio de la concesión | 2026-08-07 → 2026-07-30 (-8d) |  | 2d → 8d |  |  |  |  |
